# Target Hall shedule 130 Apr to Sep

Schedule from MS Project, 2016-04-25 to 2016-09-07.

## Calendars

- Standard: Mon-Fri 08:00-12:00, 13:00-17:00; Sat-Sun off.

## Resources

| Resource |
| --- |
| Wang.D |
| Cave.T |
| Fisher.C |
| Mjos.A |
| RPG |
| Target group |
| Mcdonald.D |

## Schedule

| ID | WBS | Task | Duration | Start | Finish | Predecessors | Total slack | Free slack | Constraint | Resources | Work |
| --- | --- | --- | --- | --- | --- | --- | --- | --- | --- | --- | --- |
| 1 | 1 | **TM2 LpTa Ready for ITW** | 26d | 2016-04-25 08:00 | 2016-05-30 17:00 |  | 72d |  |  |  | 289.04h |
| 2 | 1.1 | TM2 Leak Check -TCS | 5d | 2016-04-25 08:00 | 2016-04-29 17:00 |  | 93d |  | start no earlier than 2016-04-25 08:00 | Mjos.A; Wang.D | 80h |
| 3 | 1.2 | Module Move-TM2-TCS to silo | 0.5d | 2016-05-03 13:00 | 2016-05-03 17:00 |  | 90.5d | 0d | finish no earlier than 2016-05-03 17:00 | Cave.T; Wang.D | 8h |
| 4 | 1.3 | Module Move-TM3-Silo to TCS | 0.5d | 2016-05-04 08:00 | 2016-05-04 12:00 | 3 | 90.5d |  | finish no earlier than 2016-05-03 17:00 | Cave.T; Wang.D | 8h |
| 5 | 1.4 | TM3 Inspection-TCS | 5d | 2016-05-04 08:00 | 2016-05-10 17:00 |  | 86d |  | start no earlier than 2016-05-04 08:00 | Target group; Mcdonald.D | 80h |
| 6 | 1.5 | Module Move-TM3-TCS to Silo | 0.5d | 2016-05-11 08:00 | 2016-05-11 12:00 |  | 85d | 0d | start no earlier than 2016-05-11 08:00 | Cave.T; Wang.D | 8h |
| 7 | 1.6 | Moduel Move-TM2 Silo to SHC | 0.5d | 2016-05-11 13:00 | 2016-05-11 17:00 | 6 | 85d |  | start no earlier than 2016-05-11 08:00 | Cave.T; Wang.D | 8h |
| 8 | 1.7 | Window Line Gaskets installation-TM2 -SHC | 1d | 2016-05-12 08:00 | 2016-05-12 17:00 |  | 77.62d | 0d | start no earlier than 2016-05-12 08:00 | Fisher.C | 8h |
| 9 | 1.8 | Lp Ta Target Insert -SHC | 0.25d | 2016-05-13 08:00 | 2016-05-13 10:00 | 8 | 77.62d | 0d | start no earlier than 2016-05-13 08:00 | Fisher.C; Mjos.A | 4h |
| 10 | 1.9 | Target Installation/Electrical Check | 0.25d | 2016-05-13 10:00 | 2016-05-13 12:00 | 9 | 77.62d | 0.5d | start no earlier than 2016-05-13 08:00 | Cave.T; Fisher.C; Wang.D | 6h |
| 11 | 1.10 | Moudle Move-TM2-SHC to TCS | 0.5d | 2016-05-16 08:00 | 2016-05-16 12:00 | 10 | 77.12d | 0d | start no earlier than 2016-05-16 08:00 | Cave.T; Wang.D | 8h |
| 12 | 1.11 | Module Connection-TM2-TSC/Start of Pumps | 0.5d | 2016-05-16 13:00 | 2016-05-16 17:00 | 11 | 77.12d | 0d | start no earlier than 2016-05-16 08:00 | Wang.D | 4h |
| 13 | 1.12 | Camera Setting up-ITW | 0.13d | 2016-05-17 08:00 | 2016-05-17 09:02 | 12 | 77.12d | 0d | start no earlier than 2016-05-17 08:00 | Cave.T | 1.04h |
| 14 | 1.13 | Module Disconnection-TM1-ITW | 0.37d | 2016-05-17 09:02 | 2016-05-17 12:00 | 13 | 77.12d | 0d | start no earlier than 2016-05-17 08:00 | Wang.D | 2.96h |
| 15 | 1.14 | Module Move -TM1-SHC | 0.25d | 2016-05-17 13:00 | 2016-05-17 15:00 | 14 | 77.12d | 0d | start no earlier than 2016-05-17 08:00 | Cave.T; Wang.D | 4h |
| 16 | 1.15 | Target Remove-TM1-SHC | 0.13d | 2016-05-17 15:00 | 2016-05-17 16:02 | 15 | 77.12d | 0.12d | start no earlier than 2016-05-17 08:00 | Fisher.C | 1.04h |
| 17 | 1.16 | Module Move-TM1-SHC to Silo | 1d | 2016-05-18 08:00 | 2016-05-18 17:00 | 16 | 77d | 0d | start no earlier than 2016-05-18 08:00 | Cave.T; Wang.D | 16h |
| 18 | 1.17 | Spent Target Move | 1d | 2016-05-19 08:00 | 2016-05-19 17:00 | 17 | 77d | 3d | start no earlier than 2016-05-19 08:00 | Cave.T; Fisher.C; Wang.D | 24h |
| 19 | 1.18 | Module Disconnection-TM2-TCS | 0.25d | 2016-05-25 08:00 | 2016-05-25 10:00 | 18 | 74d | 0d | start no earlier than 2016-05-25 08:00 | Wang.D | 2h |
| 20 | 1.19 | Module Move -TM2-ITW | 0.25d | 2016-05-25 10:00 | 2016-05-25 12:00 | 19 | 74d | 0d | start no earlier than 2016-05-25 08:00 | Cave.T; Wang.D | 4h |
| 21 | 1.20 | Module Connection- TM2-ITW/ Start of Pumps | 0.5d | 2016-05-25 13:00 | 2016-05-25 17:00 | 20 | 74d | 2d | start no earlier than 2016-05-25 08:00 | Wang.D | 4h |
| 22 | 1.21 | Shielding Blocks Transfer-ITE to ITW | 1d | 2016-05-30 08:00 | 2016-05-30 17:00 | 21 | 72d |  | start no earlier than 2016-05-30 08:00 | Wang.D | 8h |
| 23 | 2 | **TM4 LP Ucx Ready for ITE** | 15d | 2016-06-07 08:00 | 2016-06-27 17:00 |  | 52d |  |  |  | 55.2h |
| 24 | 2.1 | LpUCx target Insert to SHC | 0.1d | 2016-06-07 08:00 | 2016-06-07 08:48 |  | 66.7d | 0.7d | start no earlier than 2016-06-07 08:00 | Fisher.C; Mjos.A | 1.6h |
| 25 | 2.2 | Module Disconnection-TM4 -ITE | 0.2d | 2016-06-07 15:24 | 2016-06-07 17:00 | 24 | 66d |  | finish no earlier than 2016-06-07 17:00 | Wang.D | 1.6h |
| 26 | 2.3 | Module Move-TM4-ITE to SHC | 0.2d | 2016-06-07 08:00 | 2016-06-07 09:36 |  | 60.25d | 0d | start no earlier than 2016-06-07 08:00 | Cave.T; Wang.D | 3.2h |
| 27 | 2.4 | LpUCx Installation/Electrical Check | 0.1d | 2016-06-07 09:36 | 2016-06-07 10:24 | 26 | 60.25d | 0d | start no earlier than 2016-06-07 08:00 | Cave.T; Fisher.C; Wang.D | 2.4h |
| 28 | 2.5 | Module Move-TM4-SHC to TCS | 0.2d | 2016-06-07 10:24 | 2016-06-07 12:00 | 27 | 60.25d | 0d | start no earlier than 2016-06-07 08:00 | Cave.T; Wang.D | 3.2h |
| 29 | 2.6 | Module Connection-TM4-TCS/Start of Pumps | 0.2d | 2016-06-07 13:00 | 2016-06-07 14:36 | 28 | 60.25d | 1.3d | start no earlier than 2016-06-07 08:00 | Wang.D | 1.6h |
| 30 | 2.7 | Spent Targt Move | 1d | 2016-06-09 08:00 | 2016-06-09 17:00 | 29 | 58.95d | 2d | start no earlier than 2016-06-09 08:00 | Cave.T; Fisher.C; Wang.D | 24h |
| 31 | 2.8 | Module Disconnection-TM4 -TCS | 0.2d | 2016-06-14 08:00 | 2016-06-14 09:36 | 30 | 56.95d | 0d | start no earlier than 2016-06-14 08:00 | Wang.D | 1.6h |
| 32 | 2.9 | Module Move-TM4-TSC to ITE | 0.2d | 2016-06-14 09:36 | 2016-06-14 11:12 | 31 | 56.95d | 0d | start no earlier than 2016-06-14 08:00 | Cave.T; Wang.D | 3.2h |
| 33 | 2.10 | Module connection-TM4-ITE/Start of Pumps | 0.6d | 2016-06-14 11:12 | 2016-06-14 17:00 | 32 | 56.95d | 8d | start no earlier than 2016-06-14 08:00 | Wang.D | 4.8h |
| 34 | 2.11 | shielding Blocks Transfer ITW to ITE | 1d | 2016-06-27 08:00 | 2016-06-27 17:00 | 33 | 48.95d | 5d | start no earlier than 2016-06-27 08:00 | Wang.D | 8h |

| ID | WBS | Task | Duration | Start | Finish | Predecessors | Total slack | Free slack | Constraint | Resources | Work |
| --- | --- | --- | --- | --- | --- | --- | --- | --- | --- | --- | --- |
| 35 | 3 | **TM2 HpSiC Ready for ITW** | 10d | 2016-07-05 08:00 | 2016-07-18 17:00 |  | 37d |  |  |  | 64h |
| 36 | 3.1 | HpSiC Target Insert into SHC | 0.25d | 2016-07-05 08:00 | 2016-07-05 10:00 | 34 | 43.95d | 0d | start no earlier than 2016-07-05 08:00 | Cave.T; Mjos.A | 4h |
| 37 | 3.2 | Camera Setting up-ITW | 0.25d | 2016-07-05 10:00 | 2016-07-05 12:00 | 36 | 43.95d | 0.25d | start no earlier than 2016-07-05 08:00 | Cave.T | 2h |
| 38 | 3.3 | Module Move_TM2-ITW to SHC | 0.25d | 2016-07-05 15:00 | 2016-07-05 17:00 | 37 | 43.7d | 0d | finish no earlier than 2016-07-05 17:00 | Cave.T; Wang.D | 4h |
| 39 | 3.4 | HpSiC Target Installation/Electrical Check | 0.4d | 2016-07-06 08:00 | 2016-07-06 11:12 | 38 | 43.7d | 0d | start no earlier than 2016-07-05 08:00 | Cave.T; Fisher.C; Wang.D | 9.6h |
| 40 | 3.5 | Module Move-TM2-SHC to TCS | 0.25d | 2016-07-06 11:12 | 2016-07-06 14:12 | 39 | 43.7d | 0d | start no earlier than 2016-07-06 08:00 | Cave.T; Wang.D | 4h |
| 41 | 3.6 | Module Connection-TM2-TSC/Start of Pumps | 0.25d | 2016-07-06 14:12 | 2016-07-06 16:12 | 40 | 43.7d | 0.1d | start no earlier than 2016-07-06 08:00 | Wang.D | 2h |
| 42 | 3.7 | Spent Target Move | 1d | 2016-07-07 08:00 | 2016-07-07 17:00 | 41 | 43.6d | 2d | start no earlier than 2016-07-07 08:00 | Cave.T; Fisher.C; Wang.D | 24h |
| 43 | 3.8 | Module Disconnetion-TM2-TCS | 0.2d | 2016-07-12 08:00 | 2016-07-12 09:36 | 42 | 41.6d | 0.6d | start no earlier than 2016-07-12 08:00 | Wang.D | 1.6h |
| 44 | 3.9 | Module Move-TM2-TCS to ITW | 0.2d | 2016-07-12 15:24 | 2016-07-12 17:00 | 43 | 41d |  | finish no earlier than 2016-07-12 17:00 | Cave.T; Wang.D | 3.2h |
| 45 | 3.10 | Module Connection-TM2-ITW/Start of Pumps | 0.2d | 2016-07-12 15:24 | 2016-07-12 17:00 |  | 39.9d | 3d | finish no earlier than 2016-07-12 17:00 | Wang.D | 1.6h |
| 46 | 3.11 | Shielding Blocks Transfer-ITE to ITW | 1d | 2016-07-18 08:00 | 2016-07-18 17:00 | 45 | 36.9d | 10.9d | start no earlier than 2016-07-18 08:00 | Wang.D | 8h |
| 47 | 4 | **TM4 LP Ucx Ready for ITE** | 10d | 2016-08-02 08:00 | 2016-08-15 17:00 |  | 17d |  |  |  | 53.6h |
| 48 | 4.1 | Lp Ucx target Insert into SHC | 0.1d | 2016-08-02 16:12 | 2016-08-02 17:00 | 46 | 26d |  | finish no earlier than 2016-08-02 17:00 | Fisher.C; Mjos.A | 1.6h |
| 49 | 4.2 | Module Disconnection TM4-ITE | 0.2d | 2016-08-02 08:00 | 2016-08-02 09:36 |  | 26.6d | 0.6d | start no earlier than 2016-08-02 08:00 | Wang.D | 1.6h |
| 50 | 4.3 | Module Move-TM4-ITE to SHC | 0.2d | 2016-08-02 15:24 | 2016-08-02 17:00 | 49 | 26d |  | finish no earlier than 2016-08-02 17:00 | Cave.T; Wang.D | 3.2h |
| 51 | 4.4 | UCx Target Installation/Electrical check-SHC | 0.2d | 2016-08-02 08:00 | 2016-08-02 09:36 |  | 21.8d | 0d | start no earlier than 2016-08-02 08:00 | Cave.T; Fisher.C; Wang.D | 4.8h |
| 52 | 4.5 | Module Move-TM4-SHC to TCS | 0.1d | 2016-08-02 09:36 | 2016-08-02 10:24 | 51 | 21.8d | 0d | start no earlier than 2016-08-02 08:00 | Cave.T; Wang.D | 1.6h |
| 53 | 4.6 | Module Connection-TM4-TCS/Start of Pumps | 0.1d | 2016-08-02 10:24 | 2016-08-02 11:12 | 52 | 21.8d | 1.6d | start no earlier than 2016-08-02 08:00 | Wang.D | 0.8h |
| 54 | 4.7 | Spent Target Move | 1d | 2016-08-04 08:00 | 2016-08-04 17:00 | 53 | 20.2d | 2d | start no earlier than 2016-08-04 08:00 | Cave.T; Fisher.C; Wang.D | 24h |
| 55 | 4.8 | Module Disconnection-TM4-TSC | 0.1d | 2016-08-09 08:00 | 2016-08-09 08:48 | 54 | 18.2d | 0d | start no earlier than 2016-08-09 08:00 | Wang.D | 0.8h |
| 56 | 4.9 | Module Move-TM4-TCS to ITE | 0.2d | 2016-08-09 08:48 | 2016-08-09 10:24 | 55 | 18.2d | 0d | start no earlier than 2016-08-09 08:00 | Cave.T; Wang.D | 3.2h |
| 57 | 4.10 | Module Conenction-TM4-ITE/Start of Pumps | 0.5d | 2016-08-09 10:24 | 2016-08-09 15:24 | 56 | 18.2d | 3.2d | start no earlier than 2016-08-09 08:00 | Wang.D | 4h |
| 58 | 4.11 | shielding Blocks Move | 1d | 2016-08-15 08:00 | 2016-08-15 17:00 | 57 | 15d |  | start no earlier than 2016-08-15 08:00 | Wang.D | 8h |
| 59 | 5 | New Target to SHC | 0.5d | 2016-09-06 08:00 | 2016-09-06 12:00 | 58 | 0d |  | start no earlier than 2016-09-06 08:00 | Fisher.C; Mjos.A | 8h |
| 60 | 6 | Module Disconnection-TM2-ITW | 0.25d | 2016-09-06 13:00 | 2016-09-06 15:00 | 59 | 0d |  | start no earlier than 2016-09-06 08:00 | Wang.D | 2h |
| 61 | 7 | Module Move-TM2-ITW to SHC | 0.25d | 2016-09-06 15:00 | 2016-09-06 17:00 | 60 | 0d |  | start no earlier than 2016-09-06 08:00 | Cave.T; Wang.D | 4h |
| 62 | 8 | New Target Installation/Electrical Check | 0.5d | 2016-09-07 08:00 | 2016-09-07 12:00 | 61 | 0d |  | start no earlier than 2016-09-07 08:00 | Cave.T; Fisher.C; Wang.D | 12h |
| 63 | 9 | Module Move-TM2-SHC to CS/Start of Pumps | 0.5d | 2016-09-07 13:00 | 2016-09-07 17:00 | 62 | 0d |  | start no earlier than 2016-09-07 08:00 | Wang.D | 4h |
